# bibliocal

Schedule from MS Project, 2020-04-30 to 2020-06-30, scheduled back from the finish, 7 hours a day.

## Calendars

- Standard: Mon-Fri 09:00-12:00, 14:00-18:00; Sat-Sun off. Exceptions (off unless hours are given): 2020-01-01 to 2029-01-01 (Jour de l'an, recurring), 2020-05-01 to 2029-05-01 (Fête du travail, recurring), 2020-05-08 to 2029-05-08 (Armistice 1945, recurring).

## Resources

| Resource |
| --- |
| François REY |
| Pascal HYRONDE |

## Schedule

| ID | WBS | Task | Type | Duration | Start | Finish | Predecessors | Total slack | Constraint | Resources | Work |
| --- | --- | --- | --- | --- | --- | --- | --- | --- | --- | --- | --- |
| 1 | 1 | Début du chantier | milestone | 0d | 2020-04-30 | 2020-04-30 |  | 0d |  |  |  |
| 2 | 2 | **Gestion** |  | 40.86d | 2020-04-30 | 2020-06-30 |  | 0d | as late as possible |  | 62h |
| 3 | 2.1 | Utilisateurs |  | 34h | 2020-04-30 | 2020-05-12 | 1 | 0d |  | Pascal HYRONDE | 34h |
| 4 | 2.2 | Préférences |  | 28h | 2020-06-23 | 2020-06-30 | 16 | 0d |  | Pascal HYRONDE | 28h |
| 5 | 3 | **Paramétrage** |  | 14.29d | 2020-05-12 | 2020-06-01 |  | 0d | as late as possible |  | 108h |
| 6 | 3.1 | Etablissements |  | 25h | 2020-05-12 | 2020-05-18 | 3 | 0d |  | Pascal HYRONDE | 25h |
| 7 | 3.2 | Postes |  | 22h | 2020-05-18 | 2020-05-22 | 6 | 2d |  | Pascal HYRONDE | 22h |
| 8 | 3.3 | Agents |  | 43h | 2020-05-18 | 2020-05-26 | 6 | 0d |  | François REY | 43h |
| 9 | 3.4 | Semaines types |  | 18h | 2020-05-26 | 2020-06-01 | 6, 7, 8 | 0d |  | Pascal HYRONDE | 18h |
| 10 | 4 | **Calendriers** |  | 11.57d | 2020-06-01 | 2020-06-16 |  | 0d | as late as possible |  | 67h |
| 11 | 4.1 | Absences |  | 35h | 2020-06-09 | 2020-06-16 | 12 | 0d |  | Pascal HYRONDE | 35h |
| 12 | 4.2 | Plannings |  | 32h | 2020-06-01 | 2020-06-08 | 9 | 0d |  | Pascal HYRONDE | 32h |
| 13 | 5 | **Compte-rendus** |  | 9.14d | 2020-06-17 | 2020-06-30 |  | 0d | as late as possible |  | 38h |
| 14 | 5.1 | Agents |  | 12h | 2020-06-18 | 2020-06-19 | 11 | 0d |  | Pascal HYRONDE | 12h |
| 15 | 5.2 | Postes |  | 16h | 2020-06-17 | 2020-06-19 | 11 | 0.43d |  | François REY | 16h |
| 16 | 5.3 | Etablissements |  | 10h | 2020-06-19 | 2020-06-23 | 14, 15 | 0d |  | Pascal HYRONDE | 10h |
| 17 | 5.4 | Livraison | milestone | 0d | 2020-06-30 | 2020-06-30 | 4 | 0d |  |  |  |
